Schedule from GanttProject, 2015-02-09 to 2015-06-24.

## Calendars

- Project calendar: Mon-Fri working; Sat-Sun off.

## Resources

| Resource |
| --- |
| Joe |
| Bill |
| Hal |
| Daniel |

## Schedule

| ID | WBS | Task | Type | Duration | Start | Finish | Predecessors |
| --- | --- | --- | --- | --- | --- | --- | --- |
| 1 | 1 | Initial specs receieved | milestone | 0d | 2015-02-09 | 2015-02-09 |  |
| 2 | 2 | Initial quote |  | 1d | 2015-02-09 | 2015-02-09 | 1 |
| 3 | 3 | PO RECEIVED | milestone | 0d | 2015-02-10 | 2015-02-10 | 2 |
| 4 | 4 | CREATE PROJECT FOLDER |  | 1d | 2015-02-10 | 2015-02-10 | 3 |
| 5 | 5 | FILLOUT IQ FORM |  | 1d | 2015-02-11 | 2015-02-11 | 4 |
| 6 | 6 | **REVIEW PROJECT FOLDER** |  | 1d | 2015-02-11 | 2015-02-11 | 4 |
| 7 | 6.1 | Voltage documented |  | 1d | 2015-02-11 | 2015-02-11 |  |
| 8 | 6.2 | Quotes in place |  | 1d | 2015-02-11 | 2015-02-11 |  |
| 9 | 6.3 | RFQ where necessary |  | 1d | 2015-02-11 | 2015-02-11 |  |
| 10 | 6.4 | Fill out Sales Review Form |  | 1d | 2015-02-11 | 2015-02-11 |  |
| 11 | 6.5 | Identify customizations |  | 1d | 2015-02-11 | 2015-02-11 |  |
| 12 | 6.6 | Attach Proj Mgt Progress sheet to Proj Folder |  | 1d | 2015-02-11 | 2015-02-11 |  |
| 13 | 6.7 | Clear delivery dates |  | 1d | 2015-02-11 | 2015-02-11 |  |
| 14 | 6.8 | Complete Req for Purchase Order form |  | 1d | 2015-02-11 | 2015-02-11 |  |
| 15 | 7 | LAYOUT SKETCH |  | 1d | 2015-02-09 | 2015-02-09 | 1 |
| 16 | 8 | AIRFLOW CALCULATION |  | 1d | 2015-02-10 | 2015-02-10 | 3, 15 |
| 17 | 9 | **DUCT LAYOUT DRAWING** |  | 1d | 2015-02-11 | 2015-02-11 | 16 |
| 18 | 9.1 | Review Sales Order Review Checklist |  | 1d | 2015-02-11 | 2015-02-11 |  |
| 19 | 10 | CUSTOMER REVIEW LAYOUT |  | 1d | 2015-02-12 | 2015-02-12 | 17 |
| 20 | 11 | LAYOUT APPROVED | milestone | 0d | 2015-02-13 | 2015-02-13 | 19 |
| 21 | 12 | 1st DEPOSIT RECEIVED |  | 1d | 2015-02-13 | 2015-02-13 | 20 |
| 22 | 13 | ORDER MATERIAL |  | 1d | 2015-02-16 | 2015-02-16 | 21 |
| 23 | 14 | MATERIAL LEAD (8-12wks lead) |  | 84d | 2015-02-17 | 2015-06-12 | 22 |
| 24 | 15 | CHECK DELIVERY DATES |  | 1d | 2015-06-15 | 2015-06-15 | 23 |
| 25 | 16 | Notify Customer of delivery dates |  | 1d | 2015-06-16 | 2015-06-16 | 24 |
| 26 | 17 | SCHEDULE INSTALL |  | 1d | 2015-06-16 | 2015-06-16 | 24 |
| 27 | 18 | Create Project Install Folder |  | 1d | 2015-06-17 | 2015-06-17 | 26 |
| 28 | 19 | INSTALL |  | 5d | 2015-06-18 | 2015-06-24 | 27 |
